# CREACION DEL SERVICIO DE PRÁCTICA DEPORTIVA Y/O RECREATIVA EN CASA INTEGRAL DEL ADULTO MAYOR EN LA URB. SANTA ISOLINA II ETAPA - ZONAL 11, DISTRITO DE COMAS DE LA PROVINCIA DE LIMA DEL DEPARTAMENTO DE LIMA, CON CUI N° 2678790

Schedule from MS Project, 2025-10-28 to 2026-04-30, costs in S.

## Calendars

- Estándar: Mon-Sun 02:00-05:00, 07:00-12:00.

## Schedule

| ID | WBS | Task | Type | Duration | Start | Finish | Predecessors | Baseline start | Baseline finish | Baseline duration | Total slack | Free slack | Cost | Baseline cost |
| --- | --- | --- | --- | --- | --- | --- | --- | --- | --- | --- | --- | --- | --- | --- |
| 1 | 1 | INICIO | milestone | 0d | 2025-11-01 | 2025-11-01 |  | 2025-11-01 | 2025-11-01 | 0d | -1d | 0d |  |  |
| 2 | 01 | **OBRAS PROVISIONALES, TRABAJOS PRELIMINARES, SEGURIDAD Y SALUD** |  | 180d | 2025-11-01 | 2026-04-30 | 1 | 2025-11-01 | 2026-04-30 | 180d | -1d | 0d | 68,038.05 | 199,361.89 |
| 3 | 01.01 | **OBRAS PRELIMINARES** |  | 1d | 2025-11-01 | 2025-11-02 |  | 2025-11-01 | 2025-11-02 | 1d | -1d | 0d | 4,096.25 | 4,681.8 |
| 4 | 01.01.01 | CARTEL DE IDENTIFICACION DE LA OBRA DE 3.60 X 6.00 m |  | 1d | 2025-11-01 | 2025-11-02 | 1 | 2025-11-01 | 2025-11-02 | 1d | -1d | 0d | 1,200 | 1,500 |
| 5 | 01.01.02 | CERCO PERIMETRICO PROVISIONAL DE TRIPLEY |  | 1d | 2025-11-01 | 2025-11-02 | 1SS, 4SS | 2025-11-01 | 2025-11-02 | 1d | -1d | 0d | 2,896.25 | 3,181.8 |
| 6 | 01.02 | **INSTALACIONES PROVISIONALES** |  | 180d | 2025-11-01 | 2026-04-30 | 3 | 2025-11-01 | 2026-04-30 | 180d |  |  | 19,020 | 16,200 |
| 7 | 01.02.01 | ALQUILER DE OFICINA Y ALMACEN |  | 180d | 2025-11-01 | 2026-04-30 | 1 | 2025-11-01 | 2026-04-30 | 180d | 0d |  | 9,000 | 9,000 |
| 8 | 01.02.02 | SERVICIOS HIGIENICOS PORTATIL |  | 180d | 2025-11-01 | 2026-04-30 | 1 | 2025-11-01 | 2026-04-30 | 180d | 0d |  | 10,020 | 7,200 |
| 9 | 01.03 | **ELABORACION E IMPLEMENTACION DEL PLAN DE S EGURIDAD Y SALUD EN EL TRABAJO** |  | 180d | 2025-11-01 | 2026-04-30 |  | 2025-11-01 | 2026-04-30 | 180d | 0d |  | 9,921.8 | 14,992.58 |
| 10 | 01.03.01 | PLAN DE SEGURIDAD Y SALUD EN EL TRABAJO |  | 180d | 2025-11-01 | 2026-04-30 | 1 | 2025-11-01 | 2026-04-30 | 180d | 0d |  | 2,500 | 3,000 |
| 11 | 01.03.02 | CAPACITACION EN SEGURIDAD Y SALUD |  | 180d | 2025-11-01 | 2026-04-30 | 1 | 2025-11-01 | 2026-04-30 | 180d | 0d |  | 1,500 | 1,500 |
| 12 | 01.03.03 | EQUIPAMIENTO DE PROTECCION INDIVIDUAL |  | 180d | 2025-11-01 | 2026-04-30 | 1 | 2025-11-01 | 2026-04-30 | 180d | 0d |  | 4,921.8 | 9,067.45 |
| 13 | 01.03.04 | SEÑALIZACION PARA SEGURIDAD EN OBRA |  | 180d | 2025-11-01 | 2026-04-30 | 1 | 2025-11-01 | 2026-04-30 | 180d | 0d |  | 1,000 | 1,425.13 |
| 14 | 01.04 | **MOVILIZACION DE MAQUINARIAS Y HERRAMIENTAS** |  | 4d | 2025-11-02 | 2025-11-06 |  | 2025-11-02 | 2025-11-06 | 4d | 0d |  | 5,000 | 5,500 |
| 15 | 01.04.01 | MOVILIZACION Y DESMOVILIZACION DE MAQUINARIA Y EQUIPOS |  | 4d | 2025-11-02 | 2025-11-06 | 5 | 2025-11-02 | 2025-11-06 | 4d | 0d |  | 5,000 | 5,500 |
| 16 | 01.05 | **DEMOLICIONES Y DESMONTAJES** |  | 180d | 2025-11-01 | 2026-04-30 |  | 2025-11-01 | 2026-04-30 | 180d |  |  | 30,000 | 7,262.67 |
| 17 | 01.05.01 | DEMOLICION DE ESTRUCTURAS EXISTENTES |  | 4d | 2025-11-06 | 2025-11-10 | 15 | 2025-11-01 | 2026-04-30 | 180d | 0d |  | 30,000 | 7,262.67 |
| 18 | 02 | **ESTRUCTURAS** |  | 130d | 2025-10-28 | 2026-03-07 |  | 2025-11-13 | 2026-03-08 | 115d | 0d |  | 444,429.66 | 969,850.49 |
| 19 | 02.01 | **TRABAJOS PRELIMINARES** |  | 3d | 2025-11-06 | 2025-11-09 |  |  |  |  | 0d |  | 1,234.52 |  |
| 20 | 02.01.01 | TRAZO, NIVELACIÓN Y REPLANTEO PRELIMINAR Y FINAL |  | 3d | 2025-11-06 | 2025-11-09 | 17SS |  |  |  | 0d |  | 1,234.52 |  |
| 21 | 02.02 | **MOVIMIENTO DE TIERRAS** |  | 10d | 2025-11-09 | 2025-11-19 |  |  |  |  | 0d |  | 20,078.96 |  |
| 22 | 02.02.01 | EXCAVACIÓN MANUAL DE ZANJA DE TERRENO NORMAL |  | 5d | 2025-11-09 | 2025-11-14 | 20 |  |  |  | 0d |  | 9,193.38 |  |
| 23 | 02.02.02 | RELLENO CON MATERIAL PROPIO, COMPACTADO CON EQUIPO |  | 3d | 2025-11-14 | 2025-11-17 | 22 |  |  |  | 0d |  | 2,905.7 |  |
| 24 | 02.02.03 | ELIMINACIÓN DE MATERIAL EXCENDENTE C/MAQUINARIA D=10 KM |  | 5d | 2025-11-14 | 2025-11-19 | 23SS |  |  |  | 0d |  | 7,979.88 |  |

| ID | WBS | Task | Duration | Start | Finish | Predecessors | Baseline start | Baseline finish | Baseline duration | Total slack | Free slack | Cost | Baseline cost |
| --- | --- | --- | --- | --- | --- | --- | --- | --- | --- | --- | --- | --- | --- |
| 25 | 02.03 | **CONCRETO SIMPLE** | 12d | 2025-11-14 | 2025-11-26 |  | 2025-11-21 | 2025-12-04 | 13d | 0d |  | 24,975.8 | 195,761.19 |
| 26 | 02.03.01 | **CIMIENTOS** | 6d | 2025-11-14 | 2025-11-20 |  |  |  |  | 0d |  | 8,513.34 |  |
| 27 | 02.03.01.01 | SOLADO DE CONCRETO F'C=100kg/cm2 e=0.10 m (CEMENTO TIPO V) | 3d | 2025-11-14 | 2025-11-17 | 24SS | 2025-11-21 | 2025-11-26 | 5d | 0d |  | 123 | 4,089.27 |
| 28 | 02.03.01.01 | CIMIENTO CORRIDO C:H 1;10 + 30% P.G. CON CEMENTO TIPO V | 3d | 2025-11-14 | 2025-11-17 | 27SS | 2025-11-26 | 2025-11-29 | 3d | 0d |  | 8,211.77 | 17,664.1 |
| 29 | 02.03.01.01 | CURADO DE CONCRETO C/ADITIVO T-MEMBRANIL | 3d | 2025-11-17 | 2025-11-20 | 28 | 2025-11-29 | 2025-12-04 | 5d | 0d |  | 178.57 | 174,007.82 |
| 30 | 02.03.02 | **FALSO PISO DE CONCRETO SIMPLE** | 6d | 2025-11-20 | 2025-11-26 |  |  |  |  | 155d |  | 16,462.46 |  |
| 31 | 02.03.01 | CONCRETO F'C 210KG/CM2 PARA FALSO PISO | 3d | 2025-11-20 | 2025-11-23 | 29 |  |  |  | 155d | 0d | 15,427.91 |  |
| 32 | 02.03.02.02 | CURADO DE CONCRETO C/ADITIVO T-MEMBRANIL | 3d | 2025-11-23 | 2025-11-26 | 31 |  |  |  | 155d |  | 1,034.55 |  |
| 33 | 02.04 | **CONCRETO ARMADO** | 130d | 2025-10-28 | 2026-03-07 |  | 2025-11-13 | 2026-03-08 | 115d | 0d |  | 398,140.38 | 774,089.3 |
| 34 | 02.04.01 | **ZAPATAS** | 19d | 2025-11-20 | 2025-12-09 |  | 2025-11-13 | 2025-11-25 | 12d | 0d |  | 20,926.87 | 77,774.77 |
| 35 | 02.04.01.01 | ACERO CORRUGADO FY= 4200 kg/cm2 GRADO 60 | 8d | 2025-11-23 | 2025-12-01 | 36 | 2025-11-20 | 2025-11-25 | 5d | 0d |  | 6,259.68 | 52,708.08 |
| 36 | 02.04.01.02 | SOLADO DE CONCRETO F'C=100kg/cm2 e=0.10 m (CEMENTO TIPO V) | 3d | 2025-11-20 | 2025-11-23 | 29 | 2025-11-13 | 2025-11-20 | 7d | 0d |  | 1,814.61 | 25,066.69 |
| 37 | 02.04.01.03 | CONCRETO PARA ZAPATAS FC=210 KG/CM2 | 4d | 2025-12-01 | 2025-12-05 | 35 |  |  |  | 142d | 0d | 12,368.55 |  |
| 38 | 02.04.01.04 | CURADO DE CONCRETO C/ADITIVO T-MEMBRANIL | 4d | 2025-12-05 | 2025-12-09 | 37 |  |  |  | 142d |  | 484.03 |  |
| 39 | 02.04.02 | **VIGAS DE CIMENTACION** | 16d | 2025-12-01 | 2025-12-17 |  | 2025-12-04 | 2025-12-25 | 21d | 0d |  | 4,025.86 | 22,457.23 |
| 40 | 02.04.02.01 | CONCRETO PREMEZCLADO F'C= 210 KG/CM2 | 4d | 2025-12-13 | 2025-12-17 | 41 | 2025-12-17 | 2025-12-25 | 8d | 0d |  | 2,670.28 | 4,962.49 |
| 41 | 02.04.02.01 | ENCOFRADO Y DESENCOFRADO NORMAL EN VIGAS | 6d | 2025-12-07 | 2025-12-13 | 42 | 2025-12-09 | 2025-12-17 | 8d | 0d |  | 1,329.57 | 8,667.99 |
| 42 | 02.04.02.01 | ACERO CORRUGADO FY= 4200 kg/cm2 GRADO 60 | 6d | 2025-12-01 | 2025-12-07 | 35 | 2025-12-04 | 2025-12-09 | 5d | 0d |  | 26.01 | 8,826.75 |
| 43 | 02.04.03 | **SOBRECIMIENTO** | 18d | 2025-12-17 | 2026-01-04 |  | 2025-12-04 | 2025-12-23 | 19d | 0d |  | 27,669.8 | 20,300.74 |
| 44 | 02.04.03.01 | ACERO CORRUGADO FY= 4200 kg/cm2 GRADO 60 | 5d | 2025-12-17 | 2025-12-22 | 40 | 2025-12-04 | 2025-12-10 | 6d | 0d |  | 13,009.17 | 4,860.63 |
| 45 | 02.04.03.01 | ENCOFRADO Y DESENCOFRADO EN SOBRECIMIENTO | 6d | 2025-12-22 | 2025-12-28 | 44 | 2025-12-10 | 2025-12-17 | 7d | 116d | 0d | 6,419.68 | 10,971.27 |
| 46 | 02.04.03.01 | CONCRETO EN SOBRECIMIENTO F'C=210 KG/CM2 | 4d | 2025-12-28 | 2026-01-01 | 45 | 2025-12-17 | 2025-12-23 | 6d | 116d | 0d | 7,697.35 | 4,468.84 |
| 47 | 02.04.03.01 | CURADO DE CONCRETO C/ADITIVO T-MEMBRANIL | 3d | 2026-01-01 | 2026-01-04 | 46 |  |  |  | 116d |  | 543.6 |  |
| 48 | 02.04.04 | **COLUMNAS** | 39d | 2025-12-22 | 2026-01-30 |  | 2025-12-10 | 2026-01-01 | 22d | 0d |  | 118,641.24 | 23,186.79 |
| 49 | 02.04.04.01 | ACERO CORRUGADO FY= 4200 kg/cm2 GRADO 60 EN COLUMNETAS | 12d | 2025-12-22 | 2026-01-03 | 44, 35 | 2025-12-10 | 2025-12-17 | 7d | 0d |  | 79,857.69 | 900.23 |
| 50 | 02.04.04.02 | ENCOFRADO Y DESENCOFRADO NORMAL EN COLUMNETAS | 12d | 2025-12-29 | 2026-01-10 | 49FS-5d | 2025-12-17 | 2025-12-25 | 8d | 0d |  | 17,927.55 | 17,600.96 |
| 51 | 02.04.04.03 | CONCRETO EN COLUMNAS F'C=210 KG/CM2 | 8d | 2026-01-06 | 2026-01-14 | 50FS-4d | 2025-12-25 | 2026-01-01 | 7d | 0d |  | 17,712.28 | 4,685.6 |
| 52 | 02.04.04.04 | CURADO DE CONCRETO C/ADITIVO T-MEMBRANIL | 8d | 2026-01-14 | 2026-01-22 | 51 |  |  |  | 90d | 0d | 1,925.72 |  |
| 53 | 02.04.04.05 | PROTECCION DE ACERO (columnas) INC. ENCOFRADO | 8d | 2026-01-22 | 2026-01-30 | 52 |  |  |  | 90d |  | 1,218 |  |

| ID | WBS | Task | Duration | Start | Finish | Predecessors | Baseline start | Baseline finish | Baseline duration | Total slack | Free slack | Cost | Baseline cost |
| --- | --- | --- | --- | --- | --- | --- | --- | --- | --- | --- | --- | --- | --- |
| 54 | 02.04.05 | **PLACAS** | 29d | 2025-12-07 | 2026-01-05 |  | 2025-12-10 | 2026-01-01 | 22d | 114d |  | 24,995.93 | 195,671.35 |
| 55 | 02.04.05.01 | ACERO CORRUGADO FY= 4200 kg/cm2 GRADO 60 | 12d | 2025-12-07 | 2025-12-19 | 42 | 2025-12-10 | 2025-12-17 | 7d | 114d | 0d | 10,581.62 | 60,323.4 |
| 56 | 02.04.05.02 | ENCOFRADO Y DESENCOFRADO NORMAL EN PLACAS | 12d | 2025-12-14 | 2025-12-26 | 55FS-5d | 2025-12-17 | 2025-12-25 | 8d | 115d | 0d | 10,000.58 | 59,131.42 |
| 57 | 02.04.05.03 | CONCRETO EN PLACAS F'C=210 KG/CM2 | 7d | 2025-12-26 | 2026-01-02 | 56 | 2025-12-25 | 2026-01-01 | 7d | 115d | 0d | 3,839.93 | 76,216.53 |
| 58 | 02.04.05.04 | CURADO DE CONCRETO C/ADITIVO T-MEMBRANIL | 3d | 2026-01-02 | 2026-01-05 | 57 |  |  |  | 115d |  | 573.8 |  |
| 59 | 02.04.06 | **COLUMNETAS** | 18d | 2025-12-19 | 2026-01-06 |  |  |  |  | 114d |  | 768.53 |  |
| 60 | 02.04.06.01 | ACERO CORRUGADO FY= 4200 kg/cm2 GRADO 60 | 5d | 2025-12-19 | 2025-12-24 | 55 |  |  |  | 114d | 0d | 369.1 |  |
| 61 | 02.04.06.02 | ENCOFRADO Y DESENCOFRADO NORMAL EN COLUMNETAS | 5d | 2025-12-24 | 2025-12-29 | 60 |  |  |  | 114d | 0d | 187.08 |  |
| 62 | 02.04.06.03 | CONCRETO EN COLUMNETAS F'C=210 KG/CM2 | 3d | 2025-12-29 | 2026-01-01 | 61 |  |  |  | 114d | 0d | 127.22 |  |
| 63 | 02.04.06.04 | JUNTA TECNOPORT 1" RELLENA CON SELLO ELASTOMERICO | 3d | 2026-01-01 | 2026-01-04 | 62 |  |  |  | 114d | 0d | 65.63 |  |
| 64 | 02.04.06.05 | CURADO DE CONCRETO C/ADITIVO T-MEMBRANIL | 2d | 2026-01-04 | 2026-01-06 | 63 |  |  |  | 114d |  | 19.5 |  |
| 65 | 02.04.07 | **VIGAS** | 27d | 2026-01-14 | 2026-02-10 |  | 2026-01-01 | 2026-02-28 | 58d | 0d |  | 110,581.24 | 131,407.47 |
| 66 | 02.04.07.01 | ACERO CORRUGADO FY= 4200 kg/cm2 GRADO 60 EN VIGAS | 12d | 2026-01-14 | 2026-01-26 | 51 | 2026-01-01 | 2026-01-16 | 15d | 0d |  | 74,655.2 | 51,497.1 |
| 67 | 02.04.07.02 | ENCOFRADO Y DESENCOFRADO NORMAL EN VIGAS | 10d | 2026-01-21 | 2026-01-31 | 66FS-5d | 2026-01-16 | 2026-02-10 | 25d | 79d | 0d | 14,584.95 | 46,905.21 |
| 68 | 02.04.07.03 | CONCRETO PREMEZCLADO f'c=210 kg/cm2 EN VIGAS - CEMENTO TIPO I | 5d | 2026-01-31 | 2026-02-05 | 67 | 2026-02-10 | 2026-02-20 | 10d | 79d | 0d | 19,809.24 | 31,144.37 |
| 69 | 02.04.07.04 | CURADO DE CONCRETO C/ADITIVO T-MEMBRANIL | 5d | 2026-02-05 | 2026-02-10 | 68 | 2026-02-20 | 2026-02-28 | 8d | 79d |  | 1,531.85 | 1,860.79 |
| 70 | 02.04.08 | **LOSAS ALIGERADAS** | 45d | 2026-01-21 | 2026-03-07 |  |  |  |  | 0d |  | 82,112.52 |  |
| 71 | 02.04.08.01 | ENCOFRADO Y DESENCOFRADO NORMAL EN LOSA ALIGERADA | 20d | 2026-02-01 | 2026-02-21 | 72FS-4d |  |  |  | 28d | 0d | 20,453.12 |  |
| 72 | 02.04.08.02 | ACERO CORRUGADO FY= 4200 kg/cm2 GRADO 60 | 15d | 2026-01-21 | 2026-02-05 | 66FS-5d |  |  |  | 0d |  | 23,869.8 |  |
| 73 | 02.04.08.03 | CONCRETO EN LOSA ALIGERADA F'C=210 KG/CM2 | 6d | 2026-02-24 | 2026-03-02 | 74 |  |  |  | 54d | 0d | 16,470.86 |  |
| 74 | 02.04.08.04 | LADRILLO ARCILLA PARA TECHO 15X30X30CM | 3d | 2026-02-21 | 2026-02-24 | 71 |  |  |  | 54d | 0d | 18,897.01 |  |
| 75 | 02.04.08.05 | CURADO DE CONCRETO C/ADITIVO T-MEMBRANIL | 5d | 2026-03-02 | 2026-03-07 | 73 |  |  |  | 54d |  | 2,421.73 |  |
| 76 | 02.04.09 | **LOSAS MACIZAS** | 32d | 2025-10-28 | 2025-11-29 |  | 2026-01-16 | 2026-03-08 | 51d |  |  | 1,119.96 | 247,876.33 |
| 77 | 02.04.09.01 | CONCRETO EN LOSA MACIZA F'C=210 KG/CM2 | 1d | 2026-02-10 | 2026-02-11 | 78 | 2026-02-28 | 2026-03-08 | 8d | 0d |  | 371.65 | 91,056.76 |
| 78 | 02.04.09.02 | ENCOFRADO Y DESENCOFRADO NORMAL EN LOSA MACIZA | 3d | 2026-02-07 | 2026-02-10 | 79 | 2026-01-31 | 2026-02-15 | 15d | 0d |  | 242.65 | 24,509.41 |
| 79 | 02.04.09.03 | ACERO CORRUGADO FY= 4200 kg/cm2 GRADO 60 | 2d | 2026-02-05 | 2026-02-07 | 72 | 2026-01-16 | 2026-01-31 | 15d | 0d |  | 485.47 | 131,285.7 |
| 80 | 02.04.09.04 | CURADO DE CONCRETO C/ADITIVO T-MEMBRANIL | 1d | 2026-02-11 | 2026-02-12 | 77 | 2026-02-20 | 2026-02-28 | 8d | 0d |  | 20.19 | 1,024.46 |

| ID | WBS | Task | Duration | Start | Finish | Predecessors | Baseline start | Baseline finish | Baseline duration | Total slack | Free slack | Cost | Baseline cost |
| --- | --- | --- | --- | --- | --- | --- | --- | --- | --- | --- | --- | --- | --- |
| 81 | 02.05 | **VEREDAS** | 46d | 2026-01-03 | 2026-02-18 |  |  |  |  | 71d |  | 7,298.43 |  |
| 82 | 02.05.01 | **OBRAS PRELIMINARES** | 2d | 2026-02-12 | 2026-02-14 |  | 2026-01-31 | 2026-02-23 | 23d | 75d |  | 40.19 | 40,156.93 |
| 83 | 02.05.01.01 | TRAZO, NIVELACION Y REPLANTEO PRELIMINAR Y FINAL | 2d | 2026-02-12 | 2026-02-14 | 1, 80 | 2026-02-18 | 2026-02-23 | 5d | 75d |  | 40.19 | 19,540.8 |
| 84 | 02.05.02 | **VEREDAS DE CONCRETO** | 6d | 2026-02-12 | 2026-02-18 |  | 2026-02-08 | 2026-02-18 | 10d | 71d |  | 1,986.83 | 7,767.51 |
| 85 | 02.05.02.01 | CONFORMACION DE SUBRASANTE MANUAL PARA VEREDAS | 2d | 2026-02-12 | 2026-02-14 | 80 | 2026-01-31 | 2026-02-08 | 8d | 71d | 0d | 198.01 | 12,848.62 |
| 86 | 02.05.02.02 | BASE GRANULAR E= 0.10 M. PARA VEREDAS | 3d | 2026-02-14 | 2026-02-17 | 85 |  |  |  | 72d |  | 494.35 |  |
| 87 | 02.05.02.03 | CONCRETO PREMEZCLADO EN VEREDAS F'C= 210 KG/CM2 E=0.10m INC. ACABADO FROTACHADO, BRUÑADO Y UÑA | 2d | 2026-02-15 | 2026-02-17 | 88 |  |  |  | 71d | 0d | 1,041.46 |  |
| 88 | 02.05.02.04 | ENCOFRADO Y DESENCOFRADO DE VEREDAS | 1d | 2026-02-14 | 2026-02-15 | 85 |  |  |  | 71d | 0d | 106.95 |  |
| 89 | 02.05.02.05 | RELLENO DE JUNTAS DE DILATACION EN VEREDAS CON ASFALTO E=1" (arena-asfalto 1:3) h=0.10m | 1d | 2026-02-17 | 2026-02-18 | 87 |  |  |  | 71d |  | 61.2 |  |
| 90 | 02.05.02.06 | CURADO DE CONCRETO C/ADITIVO T-MEMBRANIL | 1d | 2026-02-17 | 2026-02-18 | 87 |  |  |  | 71d |  | 84.86 |  |
| 91 | 02.06 | **ESCALERAS DE CONCRETO** | 18d | 2026-01-03 | 2026-01-21 |  |  |  |  | 83d |  | 5,271.41 |  |
| 92 | 02.06.01 | ACERO CORRUGADO FY= 4200 kg/cm2 GRADO 60 | 7d | 2026-01-03 | 2026-01-10 | 49 |  |  |  | 83d | 0d | 1,816.82 |  |
| 93 | 02.06.02 | ENCOFRADO Y DESENCOFRADO DE ESCALERAS | 5d | 2026-01-10 | 2026-01-15 | 92 |  |  |  | 83d | 0d | 1,670.43 |  |
| 94 | 02.06.03 | CIMIENTO CORRIDO C:H 1;10 + 30% P.G. CON CEMENTO TIPO I | 3d | 2026-01-15 | 2026-01-18 | 93 |  |  |  | 83d | 0d | 1,548.1 |  |
| 95 | 02.06.04 | CURADO DE CONCRETO C/ADITIVO T-MEMBRANIL | 3d | 2026-01-18 | 2026-01-21 | 94 |  |  |  | 83d | 65d | 236.06 |  |
| 96 | 03 | **ARQUITECTURA** | 77d | 2026-02-12 | 2026-04-30 |  | 2025-11-01 | 2025-11-02 | 1d? | 0d |  | 475,032.66 |  |
| 97 | 03.01 | **ALBAÑILERIA** | 10d | 2026-02-12 | 2026-02-22 |  | 2026-03-08 | 2026-03-23 | 15d | 0d |  | 83,858.75 | 98,585.38 |
| 98 | 03.01.01 | MURO DE LADRILLO K K MEZCLA 1:4 C-A, DE CABEZA | 10d | 2026-02-12 | 2026-02-22 | 77, 80 | 2026-03-08 | 2026-03-23 | 15d | 0d |  | 48,341.88 | 11,525.14 |
| 99 | 03.01.02 | MURO DE LADRILLO K K MEZCLA 1:4 C-A, DE SOGA | 10d | 2026-02-12 | 2026-02-22 | 98SS | 2026-03-08 | 2026-03-20 | 12d | 10d |  | 35,516.87 | 87,060.24 |
| 100 | 03.02 | **REVOQUES ENLUCIDOS Y MOLDURAS** | 41d | 2026-02-22 | 2026-04-04 |  | 2026-03-23 | 2026-05-02 | 40d | 0d |  | 90,790.95 | 138,212.64 |
| 101 | 03.02.01 | TARRAJEO MUROS EXT.FROTACHADO MEZ C:A 1:5 E=1.5CM INCLUYE BRUÑADO | 15d | 2026-03-04 | 2026-03-19 | 103, 99 | 2026-04-07 | 2026-04-27 | 20d | 0d |  | 6,016.66 | 55,472.06 |
| 102 | 03.02.02 | TARRAJEO MUROS INT.FROTACHADO MEZ C:A 1:5 E=1.5CM INCLUYE BRUÑADO | 15d | 2026-03-04 | 2026-03-19 | 101SS, 98 | 2026-04-07 | 2026-04-27 | 20d | 33d | 0d | 42,271.6 | 11,493.82 |
| 103 | 03.02.03 | CIELORRASOS CON MEZCLA C:A 1:5 E=1.5CM | 10d | 2026-02-22 | 2026-03-04 | 98 | 2026-03-23 | 2026-04-07 | 15d | 0d |  | 30,377.6 | 48,676.36 |
| 104 | 03.02.04 | VESTIDURA DE DERRAMES MEZ C:A 1:5 E=1.5CM | 8d | 2026-03-19 | 2026-03-27 | 102SS, 101 | 2026-04-07 | 2026-04-17 | 10d | 18d | 0d | 7,577.48 | 13,251.45 |
| 105 | 03.02.05 | TARRAJEO DE ESCALERA, PASOS Y CONTRAPASOS | 8d | 2026-03-27 | 2026-04-04 | 104, 95 | 2026-04-17 | 2026-05-02 | 15d | 18d | 0d | 4,547.61 | 9,318.95 |

| ID | WBS | Task | Duration | Start | Finish | Predecessors | Baseline start | Baseline finish | Baseline duration | Total slack | Free slack | Cost | Baseline cost |
| --- | --- | --- | --- | --- | --- | --- | --- | --- | --- | --- | --- | --- | --- |
| 106 | 03.03 | **PISOS** | 12d | 2026-03-31 | 2026-04-12 |  | 2026-05-02 | 2026-05-25 | 23d | 18d |  | 122,357.91 | 231,810.09 |
| 107 | 03.03.01 | CONTRAPISO DE E=2" (MEZCLA 1:10 CEMENTO - ARENA) | 2d | 2026-03-31 | 2026-04-02 | 105FS-4d | 2026-05-02 | 2026-05-17 | 15d | 18d | 0d | 33,127.26 | 73,900.37 |
| 108 | 03.03.02 | COBERTURA LADRILLO PASTELERO 24x24x3.5 cm ASENTADO C/MEZCLA E= 1" CON IMPERMEABILIZANTE | 4d | 2026-03-31 | 2026-04-04 | 105FS-4d | 2026-05-02 | 2026-05-17 | 15d | 21d | 0d | 12,409.95 | 114,756.34 |
| 109 | 03.03.03 | PISO PORCELANATO 0.60 X 0.60 M | 10d | 2026-04-02 | 2026-04-12 | 108FS-5d, 107 | 2026-05-17 | 2026-05-25 | 8d | 18d | 0d | 40,851.37 | 12,366.54 |
| 110 | 03.03.04 | PISO PORCELANATO 0.45 X 0.45 M | 5d | 2026-04-02 | 2026-04-07 | 105FS-4d, 107 | 2026-05-02 | 2026-05-05 | 3d | 23d |  | 18,741.02 | 30,786.84 |
| 111 | 03.03.05 | ENCHAPADO DE MUROS CON CERAMICO DE 30X30 CM DE COLOR BLANCO | 5d | 2026-04-02 | 2026-04-07 | 107 |  |  |  | 23d |  | 17,228.31 |  |
| 112 | 03.04 | **CONTRAZOCALOS** | 3d | 2026-04-03 | 2026-04-06 |  | 2026-05-17 | 2026-05-30 | 13d | 24d |  | 11,136.79 | 31,728.76 |
| 113 | 03.04.01 | CONTRAZOCALO PORCELANATO 0.60 X 0.15 M | 2d | 2026-04-04 | 2026-04-06 | 108 | 2026-05-17 | 2026-05-22 | 5d | 24d |  | 6,501.68 | 20,936.93 |
| 114 | 03.04.02 | CONTRAZOCALO PORCELANATO 0.45 X 0.15 M | 2d | 2026-04-03 | 2026-04-05 | 109FS-9d | 2026-05-25 | 2026-05-30 | 5d | 25d |  | 4,635.11 | 10,791.83 |
| 115 | 03.05 | **PINTURAS** | 37d | 2026-03-16 | 2026-04-22 |  | 2026-04-19 | 2026-05-20 | 31d | 8d |  | 38,945.97 | 55,624.6 |
| 116 | 03.05.01 | PINTADO DE CIELO RASO C/LATEX | 10d | 2026-04-12 | 2026-04-22 | 103, 118 | 2026-04-19 | 2026-04-24 | 5d | 8d |  | 10,301.64 | 13,319.67 |
| 117 | 03.05.02 | PINTADO DE MURO INTERIOR C/LATEX | 18d | 2026-03-16 | 2026-04-03 | 101FS-3d | 2026-05-07 | 2026-05-17 | 10d | 27d | 0d | 20,775.63 | 29,470.94 |
| 118 | 03.05.03 | PINTADO DE MURO EXTERIOR C/LATEX | 12d | 2026-03-31 | 2026-04-12 | 101FS+12d | 2026-05-07 | 2026-05-17 | 10d | 0d |  | 3,767.04 | 5,825.19 |
| 119 | 03.05.04 | PINTADO VESTIDURA DE DERRAMES C/LATEX | 5d | 2026-03-16 | 2026-03-21 | 117SS | 2026-05-17 | 2026-05-20 | 3d | 38d | 0d | 3,098.43 | 7,008.8 |
| 120 | 03.05.05 | PINTADO DE ESCALERA C/LATEX | 2d | 2026-03-21 | 2026-03-23 | 119 |  |  |  | 38d |  | 1,003.23 |  |
| 121 | 03.07 | **PUERTAS** | 45d | 2026-02-22 | 2026-04-08 |  | 2026-06-09 | 2026-06-30 | 21d | 12d |  | 24,449.29 | 65,382 |
| 122 | 03.07.01 | PUERTA EXTERIOR DE VIDRIO/ALUMINIO SERIE 80 | 15d | 2026-02-22 | 2026-03-09 | 98 | 2026-06-09 | 2026-06-10 | 1d | 12d | 0d | 9,414.91 | 4,053.76 |
| 123 | 03.07.02 | PUERTA INTERIOR DE VIDRIO/ALUMINIO SERIE 46 | 15d | 2026-03-09 | 2026-03-24 | 122 | 2026-06-10 | 2026-06-20 | 10d | 22d | 0d | 5,606.65 | 19,536.33 |
| 124 | 03.07.03 | PUERTA INTERIOR DE MADERA CONTRAPLACADA | 15d | 2026-03-24 | 2026-04-08 | 123, 122 | 2026-06-20 | 2026-06-30 | 10d | 22d |  | 3,811.86 | 28,911.01 |
| 125 | 03.07.04 | PUERTA EXTERIOR DE MADERA | 15d | 2026-03-24 | 2026-04-08 | 123, 122 | 2026-06-20 | 2026-06-25 | 5d | 22d |  | 5,615.87 | 12,880.9 |
| 126 | 03.08 | **VENTANAS** | 40d | 2026-03-09 | 2026-04-18 |  | 2026-06-09 | 2026-06-19 | 10d | 12d |  | 22,496.7 | 25,885.23 |
| 127 | 03.08.01 | VENTANA EXTERIOR SERIE 80 | 20d | 2026-03-09 | 2026-03-29 | 122 | 2026-06-09 | 2026-06-14 | 5d | 12d | 0d | 19,901.07 | 15,880.92 |
| 128 | 03.08.02 | VENTANA INTERIOR SERIE 62 | 20d | 2026-03-29 | 2026-04-18 | 127, 122 | 2026-06-14 | 2026-06-19 | 5d | 12d |  | 2,595.63 | 10,004.31 |
| 129 | 03.09 | **MAMPARAS** | 20d | 2026-03-09 | 2026-03-29 |  | 2026-06-14 | 2026-06-24 | 10d | 14d |  | 49,707.42 | 175,669.56 |
| 130 | 03.09.01 | MAMPARA EXTERIOR SERIE 80 | 20d | 2026-03-09 | 2026-03-29 | 122 | 2026-06-19 | 2026-06-24 | 5d | 14d |  | 49,707.42 | 168,201.33 |

| ID | WBS | Task | Duration | Start | Finish | Predecessors | Baseline start | Baseline finish | Baseline duration | Total slack | Free slack | Cost | Baseline cost |
| --- | --- | --- | --- | --- | --- | --- | --- | --- | --- | --- | --- | --- | --- |
| 131 | 03.10 | **BARANDAS** | 18d | 2026-04-12 | 2026-04-30 |  | 2026-04-19 | 2026-06-26 | 68d | 0d |  | 27,110.97 | 163,829.92 |
| 132 | 03.10.01 | BARANDA DE ACERO | 9d | 2026-04-12 | 2026-04-21 | 118, 130 | 2026-06-21 | 2026-06-24 | 3d | 0d |  | 20,160 | 21,780.98 |
| 133 | 03.10.02 | BARANDA CON VIDRIO | 9d | 2026-04-21 | 2026-04-30 | 132, 118 | 2026-06-24 | 2026-06-26 | 2d | 0d |  | 6,950.97 | 45,943.94 |
| 134 | 03.11 | **TABIQUES** | 8d | 2026-03-19 | 2026-03-27 |  |  |  |  | 34d |  | 4,177.91 |  |
| 135 | 03.11.01 | SUMINISTRO E INSTALACION DE TABIQUERIA | 8d | 2026-03-19 | 2026-03-27 | 102 |  |  |  | 34d |  | 4,177.91 |  |
| 136 | 04 | **INSTALACIONES ELECTRICAS** | 172d | 2025-11-02 | 2026-04-23 |  | 2026-04-07 | 2026-05-29 | 52d | 0d |  | 92,808.3 | 130,968.04 |
| 137 | 04.01 | **SALIDAS PARA ALUMBRADO** | 8d | 2026-02-08 | 2026-02-16 |  | 2026-04-07 | 2026-05-02 | 25d | 7d |  | 11,648.35 | 55,403.36 |
| 138 | 04.01.01 | SALIDA para ALUMBRADO | 8d | 2026-02-08 | 2026-02-16 | 72FS+3d | 2026-04-07 | 2026-04-17 | 10d | 7d | 0d | 11,648.35 | 24,887.72 |
| 139 | 04.02 | **SALIDAS PARA INTERRUPTORES** | 10d | 2026-02-16 | 2026-02-26 |  | 2026-04-17 | 2026-04-30 | 13d | 7d |  | 557.97 | 1,950.99 |
| 140 | 04.02.01 | INTERRUPTOR UNIPOLAR SIMPLE | 5d | 2026-02-16 | 2026-02-21 | 138 | 2026-04-17 | 2026-04-24 | 7d | 7d | 0d | 479.7 | 1,085.4 |
| 141 | 04.02.02 | INTERRUPTOR UNIPOLAR TRIPLE | 5d | 2026-02-21 | 2026-02-26 | 140 | 2026-04-27 | 2026-04-30 | 3d | 63d |  | 78.27 | 397.67 |
| 142 | 04.03 | **SALIDAS PARA TOMACORRIENTES** | 6d | 2026-02-21 | 2026-02-27 |  | 2026-04-24 | 2026-05-06 | 12d | 62d |  | 2,591.84 | 16,262.21 |
| 143 | 04.03.01 | SALIDA PARA TOMACORRIENTE NORMAL DE DOS DADOS | 5d | 2026-02-21 | 2026-02-26 | 140 | 2026-04-24 | 2026-04-29 | 5d | 62d | 0d | 2,531.76 | 6,366.1 |
| 144 | 04.03.02 | SALIDA PARA TOMACORRIENTE NORMAL DE UN DADO TIPO SCHUKO CON TAPA HERMETICA | 6d | 2026-02-21 | 2026-02-27 | 143SS | 2026-04-29 | 2026-05-04 | 5d | 62d |  | 60.08 | 755.3 |
| 145 | 04.04 | **SALIDAS DE FUERZA** | 2d | 2026-02-21 | 2026-02-23 |  | 2026-05-06 | 2026-05-11 | 5d | 66d |  | 1,367.34 | 1,360.59 |
| 146 | 04.04.01 | SALIDA DE FUERZA | 2d | 2026-02-21 | 2026-02-23 | 140 | 2026-05-06 | 2026-05-11 | 5d | 66d |  | 1,367.34 | 1,360.59 |
| 147 | 04.05 | **CONDUCTORES ELECTRICOS** | 37d | 2026-02-21 | 2026-03-30 |  | 2026-05-06 | 2026-05-15 | 9d | 7d |  | 37,582.19 | 7,557.81 |
| 148 | 04.05.01 | CONDUCTOR DE COBRE CABLEADO TIPO LSOH 2.5 mm2 | 10d | 2026-02-21 | 2026-03-03 | 140 | 2026-05-06 | 2026-05-11 | 5d | 7d | 0d | 1,409.21 | 5,874.24 |
| 149 | 04.05.02 | CONDUCTOR DE COBRE CABLEADO TIPO LSOH 4mm2 | 10d | 2026-02-21 | 2026-03-03 | 148SS | 2026-05-06 | 2026-05-13 | 7d | 7d | 0d | 16,637.64 | 575.25 |
| 150 | 04.05.03 | CONDUCTOR DE COBRE CABLEADO TIPO LSOH 6mm2 | 10d | 2026-02-21 | 2026-03-03 | 149SS | 2026-05-06 | 2026-05-13 | 7d | 7d | 0d | 657.21 | 540.96 |
| 151 | 04.05.04 | CONDUCTOR CABLEADO DE 95 mm2 TIPO LSOH VERDE CON FRANJAS AMARILLAS | 4d | 2026-03-03 | 2026-03-07 | 150 | 2026-05-13 | 2026-05-15 | 2d | 7d | 0d | 781.54 | 567.36 |
| 152 | 04.06 | **ACCESORIOS ELECTRICOS** | 15d | 2026-03-15 | 2026-03-30 |  | 2026-05-27 | 2026-05-29 | 2d | 31d |  | 18,096.59 | 6,864.79 |
| 153 | 04.06.01 | TUBERIA PVC-SAP ELECTRICA DE 20 mm | 8d | 2026-03-15 | 2026-03-23 | 165, 148 | 2026-05-27 | 2026-05-29 | 2d | 31d | 0d | 12,152.87 | 6,864.79 |
| 154 | 04.06.02 | TUBERIA PVC-SAP ELECTRICA DE 25 mm | 7d | 2026-03-23 | 2026-03-30 | 153 |  |  |  | 31d |  | 195.66 |  |
| 155 | 04.06.03 | TUBERIA PVC-SAP ELECTRICA DE 35 mm | 6d | 2026-03-23 | 2026-03-29 | 153 |  |  |  | 32d |  | 257.42 |  |
| 156 | 04.06.04 | CURVA PVC-SAP ELECTRICA DE 20 mm | 5d | 2026-03-23 | 2026-03-28 | 153 |  |  |  | 33d |  | 4,477.27 |  |
| 157 | 04.06.05 | CURVA PVC-SAP ELECTRICA DE 25 MM | 5d | 2026-03-23 | 2026-03-28 | 153 |  |  |  | 33d |  | 38.07 |  |
| 158 | 04.06.06 | CURVA PVC-SAP ELECTRICA DE 35 mm | 4d | 2026-03-23 | 2026-03-27 | 153 |  |  |  | 34d |  | 64.28 |  |
| 159 | 04.06.07 | CAJA DE PASO 100 X 100 X 100 MM | 4d | 2026-03-23 | 2026-03-27 | 153 |  |  |  | 31d | 0d | 911.02 |  |

| ID | WBS | Task | Duration | Start | Finish | Predecessors | Baseline start | Baseline finish | Baseline duration | Total slack | Free slack | Cost | Baseline cost |
| --- | --- | --- | --- | --- | --- | --- | --- | --- | --- | --- | --- | --- | --- |
| 160 | 04.07 | **TABLEROS ELECTRICOS** | 23d | 2026-03-07 | 2026-03-30 |  | 2026-05-15 | 2026-05-27 | 12d | 7d |  | 6,300.88 | 7,698.37 |
| 161 | 04.07.01 | TABLERO DE CONTROL BOMBA AGUA | 3d | 2026-03-27 | 2026-03-30 | 159 |  |  |  | 31d |  | 350 |  |
| 162 | 04.07.02 | **TABLEROS ELECTRICOSS** | 8d | 2026-03-07 | 2026-03-15 | 151 | 2026-05-15 | 2026-05-18 | 3d | 7d | 0d | 5,950.88 | 1,151.91 |
| 163 | 04.07.02.01 | TABLERO DE DISTRIBUCION | 2d | 2026-03-07 | 2026-03-09 |  | 2026-05-18 | 2026-05-21 | 3d | 7d | 0d | 1,502.82 | 4,739.64 |
| 164 | 04.07.02.02 | INTERRUPTORES TERMOMAGNETICOS DE 3 X 63A /10KA | 3d | 2026-03-09 | 2026-03-12 | 163 | 2026-05-21 | 2026-05-24 | 3d | 7d | 0d | 129.77 | 1,151.91 |
| 165 | 04.07.02.03 | INTERRUPTORES TERMOMAGNETICOS DE 2 X 20A /10KA | 3d | 2026-03-12 | 2026-03-15 | 164, 163 | 2026-05-24 | 2026-05-27 | 3d | 7d | 0d | 659.34 | 654.91 |
| 166 | 04.07.02.04 | INTERRUPTORES TERMOMAGNETICOS DE 2 X 25A /10KA | 4d | 2026-03-07 | 2026-03-11 |  |  |  |  | 11d |  | 195.9 |  |
| 167 | 04.07.02.05 | INTERRUPTORES DIFERENCIALES 2X25A / 30 mA DE SENSIBILIDAD | 2d | 2026-03-09 | 2026-03-11 | 163 |  |  |  | 11d |  | 2,986.55 |  |
| 168 | 04.07.02.06 | INTERRUPTOR HORARIO | 1d | 2026-03-09 | 2026-03-10 | 163 |  |  |  | 12d |  | 476.5 |  |
| 169 | 04.08 | **SISTEMA DE PUESTA A TIERRA** | 8d | 2025-11-02 | 2025-11-10 |  | 2026-05-11 | 2026-05-21 | 10d |  |  | 1,907.71 | 30,400.26 |
| 170 | 04.08.01 | SUMINISTRO E INSTALACIÓN DE POZO DE TIERRA | 3d | 2026-03-03 | 2026-03-06 | 149 | 2026-05-13 | 2026-05-16 | 3d | 8d | 0d | 1,907.71 | 18,116.3 |
| 171 | 04.09 | **LUMINARIAS Y LAMPARAS** | 15d | 2026-03-06 | 2026-03-21 | 148 | 2026-05-11 | 2026-05-14 | 3d | 7d |  | 9,943.91 | 3,038.4 |
| 172 | 04.09.01 | PANEL LED 40 W 60CM X 60CM | 5d | 2026-03-06 | 2026-03-11 | 170 | 2026-05-16 | 2026-05-21 | 5d | 8d | 0d | 2,789.58 | 9,245.56 |
| 173 | 04.09.02 | LUMINARIA DE EMERGENCIA | 3d | 2026-03-11 | 2026-03-14 | 172 | 2026-05-18 | 2026-05-21 | 3d | 8d | 1d | 3,851.75 | 3,469.66 |
| 174 | 04.09.03 | PAFLON LED 25W DIA 300MM | 1d | 2026-03-15 | 2026-03-16 | 162, 173 | 2026-05-18 | 2026-05-21 | 3d | 7d | 0d | 1,936.76 | 3,469.66 |
| 175 | 04.09.04 | DOWNLIGHT LED 9W DIA 113 MM | 3d | 2026-03-16 | 2026-03-19 | 174 |  |  |  | 7d | 0d | 1,106.1 |  |
| 176 | 04.09.05 | BRAQUETE ADOSADO EN PARED 20W | 2d | 2026-03-19 | 2026-03-21 | 175 |  |  |  | 7d | 0d | 259.72 |  |
| 177 | 04.10 | **SISTEMA CONTRA INCENDIO** | 55d | 2026-02-16 | 2026-04-12 |  |  |  |  | 18d |  | 12,905.55 |  |
| 178 | 04.10.01 | ESTACION MANUAL CONTRA INCENDIOS | 7d | 2026-03-21 | 2026-03-28 | 176 |  |  |  | 7d | 0d | 1,039.04 |  |
| 179 | 04.10.02 | CENTRAL DE ALARMA CONTRA INCENDIO | 6d | 2026-03-28 | 2026-04-03 | 178 |  |  |  | 21d | 0d | 2,168.86 |  |
| 180 | 04.10.03 | CAJA DE PASO 100 X 100 X 100 MM | 5d | 2026-03-28 | 2026-04-02 | 178 |  |  |  | 28d |  | 41.41 |  |
| 181 | 04.10.04 | CAJA DE PASO DE 150X150X75 MM | 4d | 2026-03-28 | 2026-04-01 | 178 |  |  |  | 29d |  | 44.18 |  |
| 182 | 04.10.05 | CAJA DE PASO DE 200X200X100 MM | 5d | 2026-03-28 | 2026-04-02 | 178 |  |  |  | 28d |  | 68.02 |  |
| 183 | 04.10.06 | DETECTOR DE HUMO | 6d | 2026-04-03 | 2026-04-09 | 179 |  |  |  | 21d |  | 2,772 |  |
| 184 | 04.10.07 | SIRENA CON LUZ ESTROBOSCOPICA | 7d | 2026-03-28 | 2026-04-04 | 178 |  |  |  | 26d |  | 1,868.24 |  |
| 185 | 04.10.08 | TUBERIA PVC-SAP ELECTRICA DE 25 mm | 5d | 2026-03-28 | 2026-04-02 | 178 |  |  |  | 18d | 0d | 340.27 |  |
| 186 | 04.10.09 | TUBERIA PVC-SAP ELECTRICA DE 20 mm | 10d | 2026-04-02 | 2026-04-12 | 185 |  |  |  | 18d |  | 1,538.31 |  |
| 187 | 04.10.10 | CABLE FPLR AWG N 14 | 5d | 2026-03-28 | 2026-04-02 | 178 |  |  |  | 23d | 0d | 687.18 |  |
| 188 | 04.10.11 | CABLE FPLR AWG N 18 | 5d | 2026-04-02 | 2026-04-07 | 187 |  |  |  | 23d |  | 701.31 |  |
| 189 | 04.10.12 | SUMINISTRO E INSTALACION DE GABINETE | 3d | 2026-02-16 | 2026-02-19 | 138 |  |  |  | 70d |  | 1,636.73 |  |

| ID | WBS | Task | Duration | Start | Finish | Predecessors | Baseline start | Baseline finish | Baseline duration | Total slack | Free slack | Cost | Baseline cost |
| --- | --- | --- | --- | --- | --- | --- | --- | --- | --- | --- | --- | --- | --- |
| 190 | 04.11 | **SISTEMA DE COMUNICACIONES (DATA)** | 26d | 2026-03-28 | 2026-04-23 |  |  |  |  | 7d |  | 4,949.67 |  |
| 191 | 04.11.01 | CHAPA ELECTRICA | 3d | 2026-03-28 | 2026-03-31 | 178 |  |  |  | 7d | 0d | 222.3 |  |
| 192 | 04.11.02 | INTERCOMUNICADOR | 4d | 2026-03-31 | 2026-04-04 | 191 |  |  |  | 7d | 0d | 273.52 |  |
| 193 | 04.11.03 | SALIDA PARA TELEFONO | 3d | 2026-04-04 | 2026-04-07 | 192 |  |  |  | 7d | 0d | 94.83 |  |
| 194 | 04.11.04 | SALIDA DE DATA RJ45 | 3d | 2026-04-07 | 2026-04-10 | 193 |  |  |  | 7d | 0d | 518.88 |  |
| 195 | 04.11.05 | CAJA DE PASO 100 X 100 X 100 MM | 4d | 2026-04-07 | 2026-04-11 | 194SS |  |  |  | 7d | 0d | 414.1 |  |
| 196 | 04.11.06 | CAJA DE PASO DE 150X150X75 MM | 4d | 2026-04-07 | 2026-04-11 | 195SS |  |  |  | 7d | 0d | 44.18 |  |
| 197 | 04.11.07 | CAJA DE PASO DE 200X200X100 MM | 4d | 2026-04-11 | 2026-04-15 | 196 |  |  |  | 7d | 0d | 34.01 |  |
| 198 | 04.11.08 | TUBERIA PVC-SAP ELECTRICA DE 25 mm | 4d | 2026-04-11 | 2026-04-15 | 197SS |  |  |  | 7d | 0d | 602.5 |  |
| 199 | 04.11.09 | TUBERIA PVC-SAP ELECTRICA DE 20 mm | 4d | 2026-04-11 | 2026-04-15 | 198SS |  |  |  | 7d | 0d | 1,490.75 |  |
| 200 | 04.11.10 | CURVA PVC-SAP ELECTRICA DE 20 MM | 4d | 2026-04-15 | 2026-04-19 | 199 |  |  |  | 7d | 0d | 606.1 |  |
| 201 | 04.11.11 | CABLE PARA DATA RJ45 | 4d | 2026-04-15 | 2026-04-19 | 200SS |  |  |  | 7d | 0d | 413.66 |  |
| 202 | 04.11.12 | CABLE PARA TELEFONO | 4d | 2026-04-19 | 2026-04-23 | 201 |  |  |  | 7d |  | 234.84 |  |
| 203 | 04.12 | **VARIOS** | 10d | 2026-02-21 | 2026-03-03 |  |  |  |  | 58d |  | 3,052.89 |  |
| 204 | 04.12.01 | SUMINISTRO E INSTALACIÓN DE MEDIDOR ELECTRICO | 10d | 2026-02-21 | 2026-03-03 | 140 |  |  |  | 58d |  | 3,052.89 |  |
| 205 | 05 | **INSTALACIONES SANITARIAS** | 50d | 2026-02-11 | 2026-04-02 |  | 2026-02-28 | 2026-04-13 | 44d | 28d |  | 56,381.03 | 84,790.79 |
| 206 | 05.01 | **APARATOS SANITARIOS** | 25d | 2026-02-13 | 2026-03-10 |  | 2026-03-03 | 2026-03-14 | 11d | 39d |  | 28,200.36 | 15,650.68 |
| 207 | 05.01.01 | INODORO NACIONAL SIFON JET BLANCO | 4d | 2026-02-13 | 2026-02-17 | 253 | 2026-03-03 | 2026-03-05 | 2d | 39d | 0d | 3,862.32 | 3,673.08 |
| 208 | 05.01.02 | LAVATORIO CON GRIFERIA SENSOR DE MANO | 7d | 2026-02-17 | 2026-02-24 | 207 | 2026-03-05 | 2026-03-07 | 2d | 48d | 0d | 14,924.88 | 4,803.84 |
| 209 | 05.01.03 | URINARIO NACIONAL MODELO CADET | 5d | 2026-02-24 | 2026-03-01 | 208 | 2026-03-07 | 2026-03-09 | 2d | 48d | 0d | 6,145.02 | 936.84 |
| 210 | 05.01.04 | LAVADERO DE ACERO INOXIDABLE DOS POZAS CON ESCURRIDERO | 3d | 2026-03-01 | 2026-03-04 | 209 | 2026-03-09 | 2026-03-11 | 2d | 48d | 0d | 460.78 | 390.24 |
| 211 | 05.01.05 | INSTALACION DE APARATOS SANITARIOS | 6d | 2026-03-04 | 2026-03-10 | 210 | 2026-03-11 | 2026-03-14 | 3d | 48d | 0d | 2,807.36 | 5,846.68 |
| 212 | 05.02 | **ACCESORIOS SANITARIOS** | 3d | 2026-03-10 | 2026-03-13 |  | 2026-03-14 | 2026-03-24 | 10d | 48d |  | 3,407.64 | 5,741.23 |
| 213 | 05.02.01 | DISPENSADOR DE PAPEL TOALLA | 1d | 2026-03-10 | 2026-03-11 | 211 | 2026-03-14 | 2026-03-17 | 3d | 48d | 0d | 774.48 | 471.42 |
| 214 | 05.02.02 | DISPENSADOR DE JABON | 1d | 2026-03-11 | 2026-03-12 | 213 | 2026-03-17 | 2026-03-20 | 3d | 48d | 0d | 828.96 | 42.37 |
| 215 | 05.02.03 | DISPENSADOR DE PAPEL HIGIENICO | 1d | 2026-03-12 | 2026-03-13 | 214 | 2026-03-20 | 2026-03-21 | 1d | 48d |  | 1,804.2 | 1,884.8 |

| ID | WBS | Task | Duration | Start | Finish | Predecessors | Total slack | Free slack | Cost |
| --- | --- | --- | --- | --- | --- | --- | --- | --- | --- |
| 216 | 05.03 | **SISTEMA DE DESAGUE** | 40d | 2026-02-21 | 2026-04-02 |  | 28d |  | 17,397.84 |
| 217 | 05.03.01 | **SALIDAS DE DESAGUE** | 10d | 2026-02-21 | 2026-03-03 |  | 28d |  | 4,542.52 |
| 218 | 05.03.01.01 | SALIDA DE PVC SAL PARA DESAGUE DE 2" | 5d | 2026-02-21 | 2026-02-26 | 71 | 28d | 0d | 2,615.92 |
| 219 | 05.03.01.02 | SALIDA DE PVC SAL PARA DESAGUE DE 4" | 5d | 2026-02-26 | 2026-03-03 | 218 | 48d | 0d | 1,926.6 |
| 220 | 05.03.02 | **RED DE DERIVACION Y COLECTORES** | 15d | 2026-02-26 | 2026-03-13 |  | 28d |  | 2,230.07 |
| 221 | 05.03.02.01 | TUBERIA DE DESAGUE PVC 2" | 10d | 2026-02-26 | 2026-03-08 | 218 | 28d | 0d | 542.96 |
| 222 | 05.03.02.02 | TUBERIA DE DESAGUE PVC 3" | 10d | 2026-02-26 | 2026-03-08 | 218 | 36d | 0d | 24.93 |
| 223 | 05.03.02.03 | TUBERIA DE DESAGUE PVC 4" | 10d | 2026-02-26 | 2026-03-08 | 218 | 43d | 0d | 353.36 |
| 224 | 05.03.02.04 | TUBERIA DE DESAGUE PVC 6" | 10d | 2026-03-03 | 2026-03-13 | 219 | 48d |  | 1,308.82 |
| 225 | 05.03.03 | **ACCESORIOS DE REDES** | 25d | 2026-03-08 | 2026-04-02 |  | 28d |  | 10,533.54 |
| 226 | 05.03.03.01 | CODO PVC 45° DE 2" | 5d | 2026-03-08 | 2026-03-13 | 222, 221 | 36d | 0d | 140.7 |
| 227 | 05.03.03.02 | CODO PVC 90° DE 2" | 5d | 2026-03-08 | 2026-03-13 | 221 | 28d | 0d | 875.48 |
| 228 | 05.03.03.03 | CODO PVC 90° DE 3" | 5d | 2026-03-13 | 2026-03-18 | 227 | 28d | 0d | 25.02 |
| 229 | 05.03.03.04 | CODO PVC 45° DE 4" | 5d | 2026-03-08 | 2026-03-13 | 223 | 43d | 0d | 262.46 |
| 230 | 05.03.03.05 | CODO PVC 90° DE 4" | 5d | 2026-03-13 | 2026-03-18 | 229 | 43d |  | 24.93 |
| 231 | 05.03.03.06 | TEE PVC DE 2" | 5d | 2026-03-18 | 2026-03-23 | 226, 228 | 38d |  | 492.1 |
| 232 | 05.03.03.07 | TEE PVC DE 3" | 5d | 2026-03-18 | 2026-03-23 | 228 | 28d | 0d | 19.68 |
| 233 | 05.03.03.08 | TEE PVC DE 4" | 5d | 2026-03-23 | 2026-03-28 | 232 | 28d | 0d | 474.2 |
| 234 | 05.03.03.09 | YEE PVC 2" | 5d | 2026-03-13 | 2026-03-18 | 226 | 36d | 0d | 89.56 |
| 235 | 05.03.03.10 | YEE PVC 4" | 5d | 2026-03-13 | 2026-03-18 | 226 | 43d |  | 302.94 |
| 236 | 05.03.03.11 | TEE CRUZ PVC 3" | 5d | 2026-03-13 | 2026-03-18 | 226 | 43d |  | 35.54 |
| 237 | 05.03.03.12 | REDUCCION DE 4" A 2" | 5d | 2026-03-13 | 2026-03-18 | 226 | 43d |  | 225.93 |
| 238 | 05.03.03.13 | REDUCCION DE 3" A 2" | 5d | 2026-03-13 | 2026-03-18 | 226 | 43d |  | 62.52 |
| 239 | 05.03.03.14 | REGISTRO DE BRONCE 2" | 5d | 2026-03-13 | 2026-03-18 | 226 | 43d |  | 72 |
| 240 | 05.03.03.15 | REGISTRO DE BRONCE 4" | 5d | 2026-03-13 | 2026-03-18 | 226 | 43d |  | 266.04 |
| 241 | 05.03.03.16 | SUMIDERO DE BRONCE ROSCADO 2" | 5d | 2026-03-13 | 2026-03-18 | 229 | 43d |  | 379.1 |
| 242 | 05.03.03.17 | SUMIDERO DE BRONCE ROSCADO 4" | 5d | 2026-03-28 | 2026-04-02 | 233 | 28d |  | 249.62 |
| 243 | 05.03.03.18 | SOMBRERO DE VENTILACION DE PVC DE 2" | 5d | 2026-03-18 | 2026-03-23 | 234 | 38d |  | 93.24 |
| 244 | 05.03.03.19 | SOMBRERO DE VENTILACION 3" | 5d | 2026-03-18 | 2026-03-23 | 234 | 38d |  | 33.54 |
| 245 | 05.03.03.20 | SOMBRERO DE VENTILACION 4" | 5d | 2026-03-18 | 2026-03-23 | 234 | 38d |  | 38.17 |
| 246 | 05.03.03.21 | TRAMPA DESAGUE DE 2" | 5d | 2026-03-18 | 2026-03-23 | 234 | 38d |  | 482.63 |
| 247 | 05.03.03.22 | CANALETAS DE PVC-SAL DIAMETRO 4" | 5d | 2026-03-18 | 2026-03-23 | 234 | 38d |  | 5,112.94 |
| 248 | 05.03.03.23 | CAJA DESAGUE CR N° 2 (12" X 24") | 5d | 2026-03-18 | 2026-03-23 | 234 | 36d | 0d | 775.2 |

| ID | WBS | Task | Duration | Start | Finish | Predecessors | Baseline start | Baseline finish | Baseline duration | Total slack | Free slack | Cost | Baseline cost |
| --- | --- | --- | --- | --- | --- | --- | --- | --- | --- | --- | --- | --- | --- |
| 249 | 05.03.04 | **PRUEBA HIDRAULICA** | 2d | 2026-03-23 | 2026-03-25 |  |  |  |  | 36d |  | 91.71 |  |
| 250 | 05.03.04.01 | PRUEBA HIDRAULICA DE DESAGUE | 2d | 2026-03-23 | 2026-03-25 | 248 |  |  |  | 36d |  | 91.71 |  |
| 251 | 05.03 | **SISTEMA DE AGUA FRIA** | 9d | 2026-02-11 | 2026-02-20 |  | 2026-02-28 | 2026-04-13 | 44d | 40d |  | 7,375.19 | 17,248.93 |
| 252 | 05.03.01 | **SALIDAS DE AGUA FRIA** | 2d | 2026-02-12 | 2026-02-14 |  | 2026-02-28 | 2026-03-03 | 3d | 39d |  | 3,778.9 | 5,660.1 |
| 253 | 05.04.01.01 | SALIDA DE AGUA FRIA PARA LAVADERO Y/O LAVATORIO PVC DE 1/2" | 1d | 2026-02-12 | 2026-02-13 | 80 | 2026-02-28 | 2026-03-03 | 3d | 39d | 0d | 1,584.7 | 5,660.1 |
| 254 | 05.04.01.02 | SALIDA DE AGUA FRIA PARA INODORO PVC DE 1/2" | 1d | 2026-02-13 | 2026-02-14 | 253 |  |  |  | 75d |  | 1,462.8 |  |
| 255 | 05.04.01.03 | SALIDA DE AGUA FRIA PARA URINARIO PVC DE 1/2" | 1d | 2026-02-13 | 2026-02-14 | 253 |  |  |  | 75d |  | 731.4 |  |
| 256 | 05.03.02 | **RED DE DISTRIBUCIÓN Y ALIMENTACION** | 9d | 2026-02-11 | 2026-02-20 |  | 2026-03-08 | 2026-04-13 | 36d | 69d |  | 3,596.29 | 11,588.83 |
| 257 | 05.03.02.01 | TUBERIA PVC CLASE 10 - 1/2" | 3d | 2026-02-11 | 2026-02-14 | 77 | 2026-03-08 | 2026-03-16 | 8d | 69d | 0d | 134.67 | 1,381.68 |
| 258 | 05.03.02.02 | TUBERIA PVC CLASE 10 - 3/4" | 3d | 2026-02-14 | 2026-02-17 | 257 | 2026-03-16 | 2026-03-24 | 8d | 69d | 0d | 315.88 | 3,006.42 |
| 259 | 05.03.02.03 | CODO PVC SAP 1/2"X 90º | 3d | 2026-02-14 | 2026-02-17 | 257 | 2026-03-16 | 2026-03-21 | 5d | 70d | 1d | 545.73 | 258.06 |
| 260 | 05.03.02.04 | CODO PVC SAP 3/4"X 90º | 3d | 2026-02-17 | 2026-02-20 | 258 | 2026-03-24 | 2026-03-29 | 5d | 69d |  | 58.23 | 465.8 |
| 261 | 05.03.02.05 | TEE PVC -SAP 3/4" | 1d | 2026-02-17 | 2026-02-18 | 258 | 2026-03-24 | 2026-03-29 | 5d | 69d | 0d | 138.82 | 555.2 |
| 262 | 05.03.02.06 | REDUCCION PVC -SAP 3/4"A 1/2" | 1d | 2026-02-18 | 2026-02-19 | 261, 259 | 2026-03-29 | 2026-04-03 | 5d | 69d | 0d | 182.34 | 294.72 |
| 263 | 05.03.02.07 | TEE PVC -SAP 1/2" | 1d | 2026-02-18 | 2026-02-19 | 262SS | 2026-04-03 | 2026-04-08 | 5d | 69d | 0d | 468.09 | 352.52 |
| 264 | 05.03.02.08 | UNION UNIVERSAL PVC 3/4" | 1d | 2026-02-18 | 2026-02-19 | 262SS | 2026-04-03 | 2026-04-08 | 5d | 70d |  | 1,118.22 | 737.28 |
| 265 | 05.03.02.09 | UNION UNIVERSAL PVC 1/2" | 1d | 2026-02-19 | 2026-02-20 | 263 | 2026-04-08 | 2026-04-13 | 5d | 69d |  | 30.8 | 307.2 |
| 266 | 05.03.02.10 | VALVULA COMPUERTA DE BRONCE Ø3/4" | 1d | 2026-02-17 | 2026-02-18 | 258 | 2026-03-24 | 2026-03-29 | 5d | 71d |  | 48.7 | 2,290.08 |
| 267 | 05.03.02.11 | VALVULA COMPUERTA DE BRONCE Ø1/2" | 1d | 2026-02-14 | 2026-02-15 | 257 | 2026-03-16 | 2026-03-21 | 5d | 74d |  | 92.75 | 520.87 |
| 268 | 05.03.02.12 | TUBERIA PVC CLASE 10 - 1" | 1d | 2026-02-17 | 2026-02-18 | 258 | 2026-03-24 | 2026-03-29 | 5d | 71d |  | 53.73 | 473 |
| 269 | 05.03.02.13 | TUBERIA PVC CLASE 10 - 1 1/2" | 1d | 2026-02-14 | 2026-02-15 | 257 | 2026-03-16 | 2026-03-21 | 5d | 70d | 0d | 20.52 | 946 |
| 270 | 05.04.02.14 | TEE PVC -SAP 3/4" | 3d | 2026-02-15 | 2026-02-18 | 269 |  |  |  | 71d |  | 68.32 |  |
| 271 | 05.04.02.15 | TEE PVC -SAP 1" | 3d | 2026-02-15 | 2026-02-18 | 269 |  |  |  | 71d |  | 65.76 |  |
| 272 | 05.04.02.16 | TEE PVC -SAP 1 1/4" | 3d | 2026-02-15 | 2026-02-18 | 269 |  |  |  | 71d |  | 53.46 |  |
| 273 | 05.04.02.17 | REDUCCION PVC -SAP 1" A 3/4" | 3d | 2026-02-15 | 2026-02-18 | 269 |  |  |  | 71d |  | 87.85 |  |
| 274 | 05.04.02.18 | REDUCCION PVC -SAP 3/4"A 1/2" | 3d | 2026-02-15 | 2026-02-18 | 269 |  |  |  | 71d |  | 41.04 |  |
| 275 | 05.04.02.19 | REDUCCION PVC 1 1/2" A 1 1/4" | 3d | 2026-02-15 | 2026-02-18 | 269 |  |  |  | 71d |  | 36.26 |  |
| 276 | 05.04.02.20 | REDUCCION PVC 1 1/4" A 1" | 3d | 2026-02-15 | 2026-02-18 | 269 |  |  |  | 70d | 0d | 35.12 |  |

| ID | WBS | Task | Type | Duration | Start | Finish | Predecessors | Baseline start | Baseline finish | Baseline duration | Total slack | Free slack | Cost | Baseline cost |
| --- | --- | --- | --- | --- | --- | --- | --- | --- | --- | --- | --- | --- | --- | --- |
| 277 | 05.04.03 | **PRUEBA HIDRAULICA** |  | 1d | 2026-02-18 | 2026-02-19 |  | 2026-05-29 | 2026-05-31 | 2d | 70d |  | 91.26 | 8,374.31 |
| 278 | 05.04.03.01 | PRUEBA HIDRAULICA DE RED DE AGUA |  | 1d | 2026-02-18 | 2026-02-19 | 276 | 2026-05-29 | 2026-05-30 | 1d | 70d |  | 91.26 | 1,819.79 |
| 279 | 05.04.04 | **VARIOS** |  | 150d | 2025-11-01 | 2026-03-31 |  | 2026-05-31 | 2026-06-01 | 1d | 30d |  | 129,659.76 | 200,000 |
| 280 | 05.04.04.01 | CISTERNA |  | 25d | 2026-02-17 | 2026-03-14 | 207 | 2026-05-31 | 2026-06-01 | 1d | 39d | 0d | 6,311.56 | 200,000 |
| 281 | 05.04.04.02 | BOMBA DE AGUA |  | 5d | 2026-03-14 | 2026-03-19 | 280 | 2026-06-01 | 2026-06-02 | 1d | 39d | 0d | 2,423.12 | 404,795.3 |
| 282 | 05.04.04.03 | TANQUE DE AGUA DE ETERNIT DE 1000 LITROS INCLUYE ACC. INTERNOS |  | 3d | 2026-03-19 | 2026-03-22 | 281 | 2026-06-01 | 2026-06-02 | 1d | 39d | 0d | 829.36 | 404,795.3 |
| 283 | 05.04.04.04 | SUMINISTRO E INSTALACION DE ASCENSOR |  | 150d | 2025-11-01 | 2026-03-31 | 1 | 2026-06-02 | 2026-06-14 | 12d | 30d |  | 102,095.72 | 41,120 |
| 284 | 05.04.04.05 | SUMINISTRO E INSTALACION DE ESTRUCTURA METALICA |  | 10d | 2026-03-10 | 2026-03-20 | 282FS-12d | 2026-06-02 | 2026-06-14 | 12d | 41d |  | 18,000 | 41,120 |
| 285 | 06 | **EQUIPAMIENTO Y MOBILIARIO** |  | 20d | 2025-11-01 | 2025-11-21 |  | 2025-11-01 | 2026-04-30 | 180d | 160d |  | 43,761.06 | 4,800 |
| 286 | 06.01 | EQUIPAMIENTO Y MOBILIARIO |  | 20d | 2025-11-01 | 2025-11-21 | 1 | 2025-11-01 | 2026-04-30 | 180d | 160d |  | 43,761.06 | 4,800 |
| 287 | 07 | **MITIGACION DEL IMPACTO AMBIENTAL** |  | 180d | 2025-11-01 | 2026-04-30 |  | 2026-04-30 | 2026-04-30 | 0d | 0d |  | 4,500 |  |
| 288 | 07.01 | MITIGACION DEL IMPACTO AMBIENTAL |  | 180d | 2025-11-01 | 2026-04-30 | 1 |  |  |  | 0d |  | 4,500 |  |
| 289 | 10.2 | FIN | milestone | 0d | 2026-04-30 | 2026-04-30 | 288, 284, 283, 250, 242, 204, 202, 188, 189, 161, 128, 95, 90, 75, 64, 58, 53, 47, 133, 135 |  |  |  | 0d |  |  |  |
